# project schedule

How a schedule from MS Project changed from version to version. A marks actual dates.

## Version 1 (saved 2006-01-05, file project schedule.mpp)

| ID | WBS | Task | Duration | Start | Finish | Complete | Total float | Constraint |
| --- | --- | --- | --- | --- | --- | --- | --- | --- |
| 1 | 1 | **GiGi core** | 21d? | 2005-12-08 A | 2006-01-06 | 6% | 0d |  |
| 2 |  | Final instrument modifications | 1d? | 2005-12-08 | 2005-12-08 |  | 20d |  |
| 3 | 1.2 | **Refit system valves to Cheminert valves** | 21d? | 2005-12-08 A | 2006-01-06 | 10% | 0d |  |
| 4 |  | Order new valves | 1d? | 2005-12-13 A | 2005-12-13 A | 100% |  | start no earlier than 2005-12-13 |
| 5 |  | Valves arrive | 0d | 2006-01-06 | 2006-01-06 |  | 0d | start no earlier than 2006-01-06 |
| 6 | 1.2.3 | **Valve bracket redesign** | 1d? | 2005-12-08 | 2005-12-08 |  | 20d |  |
| 7 |  | fabrication | 1d? | 2005-12-08 | 2005-12-08 |  | 20d |  |
| 8 |  | Design | 1d? | 2005-12-08 | 2005-12-08 |  | 20d |  |
| 9 |  | Part procurment | 1d? | 2005-12-08 | 2005-12-08 |  | 20d |  |
| 10 |  | Assembly | 1d? | 2005-12-08 | 2005-12-08 |  | 20d |  |
| 11 | 1.2.4 | **Valve placement in instrument** | 1d? | 2005-12-08 | 2005-12-08 |  | 20d |  |
| 12 |  | Physical modelling for valve placement | 1d? | 2005-12-08 | 2005-12-08 |  | 20d |  |
| 13 | 1.2.4.2 | **Instrument modifications** | 1d? | 2005-12-08 | 2005-12-08 |  | 20d |  |
| 14 |  | Fabrication | 1d? | 2005-12-08 | 2005-12-08 |  | 20d |  |
| 15 |  | assembly | 1d? | 2005-12-08 | 2005-12-08 |  | 20d |  |
| 16 |  | Testing | 1d? | 2005-12-08 | 2005-12-08 |  | 20d |  |
| 17 |  | Protocol redevelopment | 1d? | 2005-12-08 | 2005-12-08 |  | 20d |  |
| 18 | 1.3 | **Refit completion** | 1d? | 2005-12-08 | 2005-12-08 |  | 20d |  |
| 19 |  | Model update | 1d? | 2005-12-08 | 2005-12-08 |  | 20d |  |
| 20 |  | Drawing package update | 1d? | 2005-12-08 | 2005-12-08 |  | 20d |  |
| 22 | 1.4 | **modify bulkhead valves - eliminate solenoid** | 1d? | 2005-12-08 | 2005-12-08 |  | 20d |  |
| 23 |  | design | 1d? | 2005-12-08 | 2005-12-08 |  | 20d |  |
| 24 |  | fabricate | 1d? | 2005-12-08 | 2005-12-08 |  | 20d |  |
| 25 |  | test and integrate | 1d? | 2005-12-08 | 2005-12-08 |  | 20d |  |
| 27 | 2 | **shutter on sample intake port (50m depth max)** | 1d? | 2005-12-08 | 2005-12-08 |  | 20d |  |
| 28 |  | design | 1d? | 2005-12-08 | 2005-12-08 |  | 20d |  |
| 29 |  | fabricate | 1d? | 2005-12-08 | 2005-12-08 |  | 20d |  |
| 30 |  | test and integrate | 1d? | 2005-12-08 | 2005-12-08 |  | 20d |  |
| 32 | 3 | **Software** | 1d? | 2005-12-08 | 2005-12-08 |  | 20d |  |
| 33 |  | GUI | 1d? | 2005-12-08 | 2005-12-08 |  | 20d |  |
| 34 |  | annimator | 1d? | 2005-12-08 | 2005-12-08 |  | 20d |  |
| 36 | 4 | **Finish surface surface water GiGi** | 1d? | 2005-12-08 | 2005-12-08 |  | 20d |  |
| 37 | 4.1 | **Pressure housing for GiGi - surface water - 50m** | 1d? | 2005-12-08 | 2005-12-08 |  | 20d |  |
| 38 |  | Design | 1d? | 2005-12-08 | 2005-12-08 |  | 20d |  |
| 39 |  | assembly | 1d? | 2005-12-08 | 2005-12-08 |  | 20d |  |
| 40 |  | test (if not sent to NFESC - naval facl eng supp center alt ~ $2.5K | 1d? | 2005-12-08 | 2005-12-08 |  | 20d |  |
| 42 | 5 | **Shallow water deployments** | 1d? | 2005-12-08 | 2005-12-08 |  | 20d |  |
| 43 | 5.1 | **Deployment 1** | 1d? | 2005-12-08 | 2005-12-08 |  | 20d |  |
| 44 |  | MOB | 1d? | 2005-12-08 | 2005-12-08 |  | 20d |  |
| 45 |  | Deploy | 1d? | 2005-12-08 | 2005-12-08 |  | 20d |  |
| 46 |  | Recover | 1d? | 2005-12-08 | 2005-12-08 |  | 20d |  |
| 47 | 5.2 | **Deployment 2** | 1d? | 2005-12-08 | 2005-12-08 |  | 20d |  |
| 48 |  | MOB | 1d? | 2005-12-08 | 2005-12-08 |  | 20d |  |
| 49 |  | Deploy | 1d? | 2005-12-08 | 2005-12-08 |  | 20d |  |
| 50 |  | Recover | 1d? | 2005-12-08 | 2005-12-08 |  | 20d |  |
| 52 | 6 | **Tech xfer** | 1d? | 2005-12-08 | 2005-12-08 |  | 20d |  |
| 53 |  | Build 3 copies using exisiting design and spec, based on GiGi working | 1d? | 2005-12-08 | 2005-12-08 |  | 20d |  |
| 54 |  | initial user workshop - prep for demo deployments in 07; joint proposals | 1d? | 2005-12-08 | 2005-12-08 |  | 20d |  |
| 56 | 7 | **Finish deep water GiGI design** | 1d? | 2005-12-08 | 2005-12-08 |  | 20d |  |
| 57 | 7.1 | **D-ESP system testing** | 1d? | 2005-12-08 | 2005-12-08 |  | 20d |  |
| 58 |  | 2G ESP valves and syringes in test fixture - 4C target | 1d? | 2005-12-08 | 2005-12-08 |  | 20d |  |
| 59 |  | DWSM | 1d? | 2005-12-08 | 2005-12-08 |  | 20d |  |
| 60 |  | full system testing in prep for 'deep' ROV dive and cold water | 1d? | 2005-12-08 | 2005-12-08 |  | 20d |  |
| 61 |  | Deploy D-ESP on ROV - 2, 1day dives (2mobs) | 1d? | 2005-12-08 | 2005-12-08 |  | 20d |  |
| 62 | 7.2 | **MARS interface** | 1d? | 2005-12-08 | 2005-12-08 |  | 20d |  |
| 63 |  | Power Supply | 1d? | 2005-12-08 | 2005-12-08 |  | 20d |  |
| 64 |  | Communications interface | 1d? | 2005-12-08 | 2005-12-08 |  | 20d |  |
| 65 |  | deployment structure | 1d? | 2005-12-08 | 2005-12-08 |  | 20d |  |
| 66 |  | mob for MARS | 1d? | 2005-12-08 | 2005-12-08 |  | 20d |  |
| 67 |  | contingency/support | 1d? | 2005-12-08 | 2005-12-08 |  | 20d |  |
| 68 |  | MARS deployment | 1d? | 2005-12-08 | 2005-12-08 |  | 20d |  |
| 70 | 8 | **NASA ASTEP** | 1d? | 2005-12-08 | 2005-12-08 |  | 20d |  |
| 71 |  | system spec project start | 1d? | 2005-12-08 | 2005-12-08 |  | 20d |  |
| 72 |  | analytical mod incorp (assumes LLNL subcontract funded - PCR) | 1d? | 2005-12-08 | 2005-12-08 |  | 20d |  |
| 73 |  | ISUS context sensor incorp | 1d? | 2005-12-08 | 2005-12-08 |  | 20d |  |
| 74 |  | modify/fab DWSM | 1d? | 2005-12-08 | 2005-12-08 |  | 20d |  |
| 75 |  | Modify/fab 2G | 1d? | 2005-12-08 | 2005-12-08 |  | 20d |  |
| 76 |  | design/fab pressure housing | 1d? | 2005-12-08 | 2005-12-08 |  | 20d |  |
| 77 |  | design/fab benthic mooring structure | 1d? | 2005-12-08 | 2005-12-08 |  | 20d |  |
| 78 |  | MOOS/MARS interface (may not be needed if internal funded) | 1d? | 2005-12-08 | 2005-12-08 |  | 20d |  |

| ID | WBS | Task | Duration | Start | Finish | Total float |
| --- | --- | --- | --- | --- | --- | --- |
| 79 |  | Santa Monica Basin cruise? | 1d? | 2005-12-08 | 2005-12-08 | 20d |
| 81 | 9 | **Moore Foundation** | 1d? | 2005-12-08 | 2005-12-08 | 20d |
| 82 |  | define functional requirements (w/ Zehr) - system concept devel | 1d? | 2005-12-08 | 2005-12-08 | 20d |
| 83 |  | evaluate existing analytical modules - candidacy | 1d? | 2005-12-08 | 2005-12-08 | 20d |
| 84 |  | downselect candidate modules - develop test plan | 1d? | 2005-12-08 | 2005-12-08 | 20d |
| 85 |  | develop lab test fixture that incorps elements of ESP and analytical modules | 1d? | 2005-12-08 | 2005-12-08 | 20d |

## Version 2 (saved 2006-01-05, file ESP schedule mess.mpp)

Last finish 2006-01-06 → 2006-01-12 (+6d). Complete tasks 1 → 2.

Added:

| ID | Task | Duration | Start | Finish | Predecessors | Resources |
| --- | --- | --- | --- | --- | --- | --- |
| 5 | Split cost of valves | 0d | 2006-01-04 A | 2006-01-04 A |  |  |
| 8 | **fabrication** | 1d? | 2006-01-04 | 2006-01-04 |  |  |
| 9 | METech | 1d? | 2006-01-04 | 2006-01-04 |  |  |
| 10 | ME | 1d? | 2006-01-04 | 2006-01-04 |  |  |
| 11 | EE | 1d? | 2006-01-04 | 2006-01-04 |  |  |
| 12 | **Design** | 2d? | 2006-01-04 | 2006-01-05 |  |  |
| 13 | EE | 1.43d? | 2006-01-04 | 2006-01-05 |  | Scott [70%] |
| 14 | ME | 2d? | 2006-01-04 | 2006-01-05 |  | Gene [50%] |
| 15 | SE | 1.43d? | 2006-01-04 | 2006-01-05 |  | Brent [70%] |
| 17 | ME Tech | 1d? | 2006-01-04 | 2006-01-04 |  |  |
| 18 | ME | 2d? | 2006-01-04 | 2006-01-05 |  | Gene [50%] |
| 20 | ME Tech | 1d? | 2006-01-04 | 2006-01-04 |  |  |
| 26 | **Testing** | 1d? | 2006-01-04 | 2006-01-04 |  |  |
| 27 | Sci Tech | 1d? | 2006-01-04 | 2006-01-04 |  | Roman |
| 29 | **Protocol redevelopment** | 1d? | 2006-01-04 | 2006-01-04 |  |  |
| 30 | Sci Tech | 1d? | 2006-01-04 | 2006-01-04 |  | Roman |
| 31 | EE | 1d? | 2006-01-04 | 2006-01-04 |  | Scott |
| 32 | Sci | 1d? | 2006-01-04 | 2006-01-04 |  | Chris S. |
| 38 | **design** | 7d? | 2006-01-04 | 2006-01-12 |  |  |
| 41 | SE | 2d? | 2006-01-04 | 2006-01-05 |  | Brent |
| 42 | METech | 1d? | 2006-01-04 | 2006-01-04 |  |  |
| 43 | EETech | 1d? | 2006-01-04 | 2006-01-04 |  |  |
| 44 | Shop | 1d? | 2006-01-04 | 2006-01-04 |  |  |
| 45 | **fabricate** | 1d? | 2006-01-04 | 2006-01-04 |  |  |
| 46 | EE | 1d? | 2006-01-04 | 2006-01-04 |  |  |
| 47 | ME | 1d? | 2006-01-04 | 2006-01-04 |  |  |
| 48 | SE | 1d? | 2006-01-04 | 2006-01-04 |  |  |
| 49 | METech | 1d? | 2006-01-04 | 2006-01-04 |  |  |
| 50 | EETech | 1d? | 2006-01-04 | 2006-01-04 |  |  |
| 51 | Shop | 1d? | 2006-01-04 | 2006-01-04 |  |  |
| 52 | **test and integrate** | 1d? | 2006-01-04 | 2006-01-04 |  |  |
| 53 | EE | 1d? | 2006-01-04 | 2006-01-04 |  |  |
| 54 | ME | 1d? | 2006-01-04 | 2006-01-04 |  |  |
| 55 | SE | 1d? | 2006-01-04 | 2006-01-04 |  |  |
| 56 | METech | 1d? | 2006-01-04 | 2006-01-04 |  |  |
| 57 | EETech | 1d? | 2006-01-04 | 2006-01-04 |  |  |
| 58 | Shop | 1d? | 2006-01-04 | 2006-01-04 |  |  |
| 61 | **design** | 1d? | 2006-01-04 | 2006-01-04 |  |  |
| 62 | EE | 1d? | 2006-01-04 | 2006-01-04 |  |  |
| 63 | ME | 1d? | 2006-01-04 | 2006-01-04 |  |  |
| 64 | SE | 1d? | 2006-01-04 | 2006-01-04 |  |  |
| 65 | METech | 1d? | 2006-01-04 | 2006-01-04 |  |  |
| 66 | EETech | 1d? | 2006-01-04 | 2006-01-04 |  |  |
| 67 | Shop | 1d? | 2006-01-04 | 2006-01-04 |  |  |
| 68 | **fabricate** | 1d? | 2006-01-04 | 2006-01-04 |  |  |
| 69 | EE | 1d? | 2006-01-04 | 2006-01-04 |  |  |
| 70 | ME | 1d? | 2006-01-04 | 2006-01-04 |  |  |
| 71 | SE | 1d? | 2006-01-04 | 2006-01-04 |  |  |
| 72 | METech | 1d? | 2006-01-04 | 2006-01-04 |  |  |
| 73 | EETech | 1d? | 2006-01-04 | 2006-01-04 |  |  |
| 74 | Shop | 1d? | 2006-01-04 | 2006-01-04 |  |  |
| 75 | **test and integrate** | 1d? | 2006-01-04 | 2006-01-04 |  |  |
| 76 | EE | 1d? | 2006-01-04 | 2006-01-04 |  |  |
| 77 | ME | 1d? | 2006-01-04 | 2006-01-04 |  |  |
| 78 | SE | 1d? | 2006-01-04 | 2006-01-04 |  |  |
| 79 | METech | 1d? | 2006-01-04 | 2006-01-04 |  |  |
| 80 | EETech | 1d? | 2006-01-04 | 2006-01-04 |  |  |
| 81 | Shop | 1d? | 2006-01-04 | 2006-01-04 |  |  |
| 89 | **Design** | 1d? | 2006-01-04 | 2006-01-04 |  |  |
| 90 | EE | 1d? | 2006-01-04 | 2006-01-04 |  |  |
| 91 | ME | 1d? | 2006-01-04 | 2006-01-04 |  |  |
| 92 | SE | 1d? | 2006-01-04 | 2006-01-04 |  |  |
| 93 | METech | 1d? | 2006-01-04 | 2006-01-04 |  |  |
| 94 | EETech | 1d? | 2006-01-04 | 2006-01-04 |  |  |
| 95 | Shop | 1d? | 2006-01-04 | 2006-01-04 |  |  |
| 96 | **assembly** | 1d? | 2006-01-04 | 2006-01-04 |  |  |
| 97 | EE | 1d? | 2006-01-04 | 2006-01-04 |  |  |
| 98 | ME | 1d? | 2006-01-04 | 2006-01-04 |  |  |
| 99 | SE | 1d? | 2006-01-04 | 2006-01-04 |  |  |
| 100 | METech | 1d? | 2006-01-04 | 2006-01-04 |  |  |
| 101 | EETech | 1d? | 2006-01-04 | 2006-01-04 |  |  |
| 102 | Shop | 1d? | 2006-01-04 | 2006-01-04 |  |  |
| 103 | **test (if not sent to NFESC - naval facl eng supp center alt ~ $2.5K** | 1d? | 2006-01-04 | 2006-01-04 |  |  |
| 104 | EE | 1d? | 2006-01-04 | 2006-01-04 |  |  |
| 105 | ME | 1d? | 2006-01-04 | 2006-01-04 |  |  |
| 106 | SE | 1d? | 2006-01-04 | 2006-01-04 |  |  |
| 107 | METech | 1d? | 2006-01-04 | 2006-01-04 |  |  |
| 108 | EETech | 1d? | 2006-01-04 | 2006-01-04 |  |  |
| 109 | Shop | 1d? | 2006-01-04 | 2006-01-04 |  |  |
| 114 | EE | 1d? | 2006-01-04 | 2006-01-04 |  | Scott |
| 115 | ME | 1d? | 2006-01-04 | 2006-01-04 |  |  |
| 116 | SE | 1d? | 2006-01-04 | 2006-01-04 |  |  |
| 117 | METech | 1d? | 2006-01-04 | 2006-01-04 |  |  |
| 118 | EETech | 1d? | 2006-01-04 | 2006-01-04 |  |  |
| 119 | Shop | 1d? | 2006-01-04 | 2006-01-04 |  |  |
| 120 | **Deployment** | 1d? | 2006-01-05 | 2006-01-05 | 113 |  |
| 121 | EE | 1d? | 2006-01-05 | 2006-01-05 |  |  |
| 122 | ME | 1d? | 2006-01-05 | 2006-01-05 |  |  |
| 123 | SE | 1d? | 2006-01-05 | 2006-01-05 |  |  |
| 124 | METech | 1d? | 2006-01-05 | 2006-01-05 |  |  |
| 125 | EETech | 1d? | 2006-01-05 | 2006-01-05 |  |  |
| 126 | Shop | 1d? | 2006-01-05 | 2006-01-05 |  |  |
| 128 | **MOB** | 6d? | 2006-01-04 | 2006-01-11 |  |  |
| 129 | EE | 1d? | 2006-01-04 | 2006-01-04 |  |  |
| 130 | ME | 1d? | 2006-01-05 | 2006-01-05 | 129 |  |
| 131 | SE | 1d? | 2006-01-06 | 2006-01-06 | 130 |  |
| 132 | METech | 1d? | 2006-01-09 | 2006-01-09 | 131 |  |
| 133 | EETech | 1d? | 2006-01-10 | 2006-01-10 | 132 |  |
| 134 | Shop | 1d? | 2006-01-11 | 2006-01-11 | 133 |  |
| 135 | **Deployment** | 1d? | 2006-01-12 | 2006-01-12 | 134 |  |
| 136 | EE | 1d? | 2006-01-12 | 2006-01-12 |  |  |
| 137 | ME | 1d? | 2006-01-12 | 2006-01-12 |  |  |
| 138 | SE | 1d? | 2006-01-12 | 2006-01-12 |  |  |
| 139 | METech | 1d? | 2006-01-12 | 2006-01-12 |  |  |
| 140 | EETech | 1d? | 2006-01-12 | 2006-01-12 |  |  |
| 141 | Shop | 1d? | 2006-01-12 | 2006-01-12 |  |  |
| 142 | **Deployment 3** | 7d? | 2006-01-04 | 2006-01-12 |  |  |
| 143 | **MOB** | 6d? | 2006-01-04 | 2006-01-11 |  |  |
| 144 | EE | 1d? | 2006-01-04 | 2006-01-04 |  |  |
| 145 | ME | 1d? | 2006-01-05 | 2006-01-05 | 144 |  |
| 146 | SE | 1d? | 2006-01-06 | 2006-01-06 | 145 |  |
| 147 | METech | 1d? | 2006-01-09 | 2006-01-09 | 146 |  |
| 148 | EETech | 1d? | 2006-01-10 | 2006-01-10 | 147 |  |
| 149 | Shop | 1d? | 2006-01-11 | 2006-01-11 | 148 |  |
| 150 | **Deployment** | 1d? | 2006-01-12 | 2006-01-12 | 149 |  |
| 151 | EE | 1d? | 2006-01-12 | 2006-01-12 |  |  |
| 152 | ME | 1d? | 2006-01-12 | 2006-01-12 |  |  |
| 153 | SE | 1d? | 2006-01-12 | 2006-01-12 |  |  |
| 154 | METech | 1d? | 2006-01-12 | 2006-01-12 |  |  |
| 155 | EETech | 1d? | 2006-01-12 | 2006-01-12 |  |  |
| 156 | Shop | 1d? | 2006-01-12 | 2006-01-12 |  |  |
| 157 | **Deployment 4** | 7d? | 2006-01-04 | 2006-01-12 |  |  |
| 158 | **MOB** | 6d? | 2006-01-04 | 2006-01-11 |  |  |
| 159 | EE | 1d? | 2006-01-04 | 2006-01-04 |  |  |
| 160 | ME | 1d? | 2006-01-05 | 2006-01-05 | 159 |  |
| 161 | SE | 1d? | 2006-01-06 | 2006-01-06 | 160 |  |
| 162 | METech | 1d? | 2006-01-09 | 2006-01-09 | 161 |  |
| 163 | EETech | 1d? | 2006-01-10 | 2006-01-10 | 162 |  |
| 164 | Shop | 1d? | 2006-01-11 | 2006-01-11 | 163 |  |
| 165 | **Deployment** | 1d? | 2006-01-12 | 2006-01-12 | 164 |  |
| 166 | EE | 1d? | 2006-01-12 | 2006-01-12 |  |  |
| 167 | ME | 1d? | 2006-01-12 | 2006-01-12 |  |  |
| 168 | SE | 1d? | 2006-01-12 | 2006-01-12 |  |  |
| 169 | METech | 1d? | 2006-01-12 | 2006-01-12 |  |  |
| 170 | EETech | 1d? | 2006-01-12 | 2006-01-12 |  |  |
| 171 | Shop | 1d? | 2006-01-12 | 2006-01-12 |  |  |
| 172 | **Deployment 5** | 7d? | 2006-01-04 | 2006-01-12 |  |  |
| 173 | **MOB** | 6d? | 2006-01-04 | 2006-01-11 |  |  |
| 174 | EE | 1d? | 2006-01-04 | 2006-01-04 |  |  |
| 175 | ME | 1d? | 2006-01-05 | 2006-01-05 | 174 |  |
| 176 | SE | 1d? | 2006-01-06 | 2006-01-06 | 175 |  |
| 177 | METech | 1d? | 2006-01-09 | 2006-01-09 | 176 |  |
| 178 | EETech | 1d? | 2006-01-10 | 2006-01-10 | 177 |  |
| 179 | Shop | 1d? | 2006-01-11 | 2006-01-11 | 178 |  |
| 180 | **Deployment** | 1d? | 2006-01-12 | 2006-01-12 | 179 |  |
| 181 | EE | 1d? | 2006-01-12 | 2006-01-12 |  |  |
| 182 | ME | 1d? | 2006-01-12 | 2006-01-12 |  |  |
| 183 | SE | 1d? | 2006-01-12 | 2006-01-12 |  |  |
| 184 | METech | 1d? | 2006-01-12 | 2006-01-12 |  |  |
| 185 | EETech | 1d? | 2006-01-12 | 2006-01-12 |  |  |
| 186 | Shop | 1d? | 2006-01-12 | 2006-01-12 |  |  |
| 189 | EE | 1d? | 2006-01-04 | 2006-01-04 |  |  |
| 190 | ME | 1d? | 2006-01-05 | 2006-01-05 | 189 |  |
| 191 | SE | 1d? | 2006-01-06 | 2006-01-06 | 190 |  |
| 192 | METech | 1d? | 2006-01-09 | 2006-01-09 | 191 |  |
| 193 | EETech | 1d? | 2006-01-10 | 2006-01-10 | 192 |  |
| 194 | Shop | 1d? | 2006-01-11 | 2006-01-11 | 193 |  |
| 195 | **Deployment** | 1d? | 2006-01-12 | 2006-01-12 | 194 |  |
| 196 | EE | 1d? | 2006-01-12 | 2006-01-12 |  |  |
| 197 | ME | 1d? | 2006-01-12 | 2006-01-12 |  |  |
| 198 | SE | 1d? | 2006-01-12 | 2006-01-12 |  |  |
| 199 | METech | 1d? | 2006-01-12 | 2006-01-12 |  |  |
| 200 | EETech | 1d? | 2006-01-12 | 2006-01-12 |  |  |
| 201 | Shop | 1d? | 2006-01-12 | 2006-01-12 |  |  |

Removed: 7 fabrication; 8 Design; 9 Part procurment; 10 Assembly; 16 Testing; 17 Protocol redevelopment; 23 design; 24 fabricate; 25 test and integrate; 30 test and integrate; 38 Design; 39 assembly; 40 test (if not sent to NFESC - naval facl eng supp center alt ~ $2.5K

Changed:

| ID | Task | Start | Finish | Duration | Complete | Total float | Other |
| --- | --- | --- | --- | --- | --- | --- | --- |
| 1 | **GiGi core** | 2005-12-08 A → 2005-12-14 A (+6d) | 2006-01-06 → 2006-01-12 (+6d) | 21d? → 22d? | 6% → 1% |  | baseline start none → 2005-12-14; baseline finish none → 2006-01-04 |
| 2 | Final instrument modifications | 2005-12-08 → 2006-01-04 (+27d) | 2005-12-08 → 2006-01-04 (+27d) |  |  | 20d → 6d | baseline start none → 2006-01-04; baseline finish none → 2006-01-04 |
| 3 | **Refit system valves to Cheminert valves** | 2005-12-08 A → 2005-12-14 A (+6d) | 2006-01-06 → 2006-01-04 (-2d) | 21d? → 15d | 10% → 99% | 0d → 7d | baseline start none → 2005-12-14; baseline finish none → 2006-01-04 |
| 4 | Order new valves | 2005-12-13 A → 2005-12-14 A (+1d) | 2005-12-13 A → 2005-12-14 A (+1d) | 1d? → 0.5d |  |  | constraint start no earlier than 2005-12-13 → start no earlier than 2005-12-14; resources Scott [40%] → Scott; baseline start none → 2005-12-14; baseline finish none → 2005-12-14 |
| 6 | Valves arrive | 2006-01-06 → 2006-01-04 (-2d) | 2006-01-06 → 2006-01-04 (-2d) |  |  | 0d → 7d | constraint start no earlier than 2006-01-06 → none; baseline start none → 2006-01-04; baseline finish none → 2006-01-04 |
| 7 | **Valve bracket redesign** | 2005-12-08 → 2006-01-04 (+27d) | 2005-12-08 → 2006-01-05 (+28d) | 1d? → 2d? |  | 20d → 5d | baseline start none → 2006-01-04; baseline finish none → 2006-01-04 |
| 16 | **Part procurment** | 2005-12-08 → 2006-01-04 (+27d) | 2005-12-08 → 2006-01-05 (+28d) | 1d? → 2d? |  | 20d → 5d | was named design; baseline start none → 2006-01-04; baseline finish none → 2006-01-04 |
| 19 | **Assembly** | 2005-12-08 → 2006-01-04 (+27d) | 2005-12-08 → 2006-01-04 (+27d) |  |  | 20d → 6d | was named fabricate; baseline start none → 2006-01-04; baseline finish none → 2006-01-04 |
| 21 | **Valve placement in instrument** | 2005-12-08 → 2006-01-04 (+27d) | 2005-12-08 → 2006-01-04 (+27d) |  |  | 20d → 6d | baseline start none → 2006-01-04; baseline finish none → 2006-01-04 |
| 22 | Physical modelling for valve placement | 2005-12-08 → 2006-01-04 (+27d) | 2005-12-08 → 2006-01-04 (+27d) |  |  | 20d → 6d | baseline start none → 2006-01-04; baseline finish none → 2006-01-04 |
| 23 | **Instrument modifications** | 2005-12-08 → 2006-01-04 (+27d) | 2005-12-08 → 2006-01-04 (+27d) |  |  | 20d → 6d | baseline start none → 2006-01-04; baseline finish none → 2006-01-04 |
| 24 | Fabrication | 2005-12-08 → 2006-01-04 (+27d) | 2005-12-08 → 2006-01-04 (+27d) |  |  | 20d → 6d | baseline start none → 2006-01-04; baseline finish none → 2006-01-04 |
| 25 | assembly | 2005-12-08 → 2006-01-04 (+27d) | 2005-12-08 → 2006-01-04 (+27d) |  |  | 20d → 6d | baseline start none → 2006-01-04; baseline finish none → 2006-01-04 |
| 28 | EE | 2005-12-08 → 2006-01-04 (+27d) | 2005-12-08 → 2006-01-04 (+27d) |  |  | 20d → 6d | was named MOB; resources none → Scott; baseline start none → 2006-01-04; baseline finish none → 2006-01-04 |
| 33 | **Refit completion** | 2005-12-08 → 2006-01-04 (+27d) | 2005-12-08 → 2006-01-04 (+27d) |  |  | 20d → 6d | baseline start none → 2006-01-04; baseline finish none → 2006-01-04 |
| 34 | Model update | 2005-12-08 → 2006-01-04 (+27d) | 2005-12-08 → 2006-01-04 (+27d) |  |  | 20d → 6d | resources none → Mark B; baseline start none → 2006-01-04; baseline finish none → 2006-01-04 |
| 35 | Drawing package update | 2005-12-08 → 2006-01-04 (+27d) | 2005-12-08 → 2006-01-04 (+27d) |  |  | 20d → 6d | resources none → Mark B; baseline start none → 2006-01-04; baseline finish none → 2006-01-04 |
| 37 | **modify bulkhead valves - eliminate solenoid** | 2005-12-08 → 2006-01-04 (+27d) | 2005-12-08 → 2006-01-12 (+35d) | 1d? → 7d? |  | 20d → 0d | baseline start none → 2006-01-04; baseline finish none → 2006-01-04 |
| 39 | EE | 2005-12-08 → 2006-01-04 (+27d) | 2005-12-08 → 2006-01-10 (+33d) | 1d? → 5d? |  | 20d → 2d | was named Deploy; resources none → Scott; baseline start none → 2006-01-04; baseline finish none → 2006-01-10 |
| 40 | ME | 2005-12-08 → 2006-01-04 (+27d) | 2005-12-08 → 2006-01-12 (+35d) | 1d? → 7d? |  | 20d → 0d | was named Recover; resources none → Gene; baseline start none → 2006-01-04; baseline finish none → 2006-01-12 |
| 60 | **shutter on sample intake port (50m depth max)** | 2005-12-08 → 2006-01-04 (+27d) | 2005-12-08 → 2006-01-04 (+27d) |  |  | 20d → 6d | baseline start none → 2006-01-04; baseline finish none → 2006-01-04 |
| 83 | **Software** | 2005-12-08 → 2006-01-04 (+27d) | 2005-12-08 → 2006-01-04 (+27d) |  |  | 20d → 6d | baseline start none → 2006-01-04; baseline finish none → 2006-01-04 |
| 84 | GUI | 2005-12-08 → 2006-01-04 (+27d) | 2005-12-08 → 2006-01-04 (+27d) |  |  | 20d → 6d | baseline start none → 2006-01-04; baseline finish none → 2006-01-04 |
| 85 | annimator | 2005-12-08 → 2006-01-04 (+27d) | 2005-12-08 → 2006-01-04 (+27d) |  |  | 20d → 6d | resources none → Brent [3500%]; baseline start none → 2006-01-04; baseline finish none → 2006-01-04 |
| 87 | **Finish surface surface water GiGi** | 2005-12-08 → 2006-01-04 (+27d) | 2005-12-08 → 2006-01-04 (+27d) |  |  | 20d → 6d | baseline start none → 2006-01-04; baseline finish none → 2006-01-04 |
| 88 | **Pressure housing for GiGi - surface water - 50m** | 2005-12-08 → 2006-01-04 (+27d) | 2005-12-08 → 2006-01-04 (+27d) |  |  | 20d → 6d | baseline start none → 2006-01-04; baseline finish none → 2006-01-04 |
| 111 | **Shallow water deployments** | 2005-12-08 → 2006-01-04 (+27d) | 2005-12-08 → 2006-01-12 (+35d) | 1d? → 7d? |  | 20d → 0d | baseline start none → 2006-01-04; baseline finish none → 2006-03-08 |
| 112 | **Deployment 1** | 2005-12-08 → 2006-01-04 (+27d) | 2005-12-08 → 2006-01-05 (+28d) | 1d? → 2d? |  | 20d → 5d | baseline start none → 2006-01-04; baseline finish none → 2006-03-08 |
| 113 | MOB | 2005-12-08 → 2006-01-04 (+27d) | 2005-12-08 → 2006-01-04 (+27d) | 1d? → 1d |  | 20d → 5d | baseline start none → 2006-01-04; baseline finish none → 2006-01-04 |
| 127 | **Deployment 2** | 2005-12-08 → 2006-01-04 (+27d) | 2005-12-08 → 2006-01-12 (+35d) | 1d? → 7d? |  | 20d → 0d | baseline start none → 2006-01-04; baseline finish none → 2006-01-04 |
| 187 | **Deployment 6** | 2005-12-08 → 2006-01-04 (+27d) | 2005-12-08 → 2006-01-12 (+35d) | 1d? → 7d? |  | 20d → 0d | was named Deploy; baseline start none → 2006-01-04; baseline finish none → 2006-01-04 |
| 188 | **MOB** | 2005-12-08 → 2006-01-04 (+27d) | 2005-12-08 → 2006-01-11 (+34d) | 1d? → 6d? |  | 20d → 0d | was named Recover; baseline start none → 2006-01-04; baseline finish none → 2006-01-04 |
| 203 | **Tech xfer** | 2005-12-08 → 2006-01-04 (+27d) | 2005-12-08 → 2006-01-04 (+27d) |  |  | 20d → 6d | baseline start none → 2006-01-04; baseline finish none → 2006-01-04 |
| 204 | Build 3 copies using exisiting design and spec, based on GiGi working | 2005-12-08 → 2006-01-04 (+27d) | 2005-12-08 → 2006-01-04 (+27d) |  |  | 20d → 6d | baseline start none → 2006-01-04; baseline finish none → 2006-01-04 |
| 205 | initial user workshop - prep for demo deployments in 07; joint proposals | 2005-12-08 → 2006-01-04 (+27d) | 2005-12-08 → 2006-01-04 (+27d) |  |  | 20d → 6d | baseline start none → 2006-01-04; baseline finish none → 2006-01-04 |
| 207 | **Finish deep water GiGI design** | 2005-12-08 → 2006-01-04 (+27d) | 2005-12-08 → 2006-01-04 (+27d) |  |  | 20d → 6d | baseline start none → 2006-01-04; baseline finish none → 2006-01-04 |
| 208 | **D-ESP system testing** | 2005-12-08 → 2006-01-04 (+27d) | 2005-12-08 → 2006-01-04 (+27d) |  |  | 20d → 6d | baseline start none → 2006-01-04; baseline finish none → 2006-01-04 |
| 209 | 2G ESP valves and syringes in test fixture - 4C target | 2005-12-08 → 2006-01-04 (+27d) | 2005-12-08 → 2006-01-04 (+27d) |  |  | 20d → 6d | baseline start none → 2006-01-04; baseline finish none → 2006-01-04 |
| 210 | DWSM | 2005-12-08 → 2006-01-04 (+27d) | 2005-12-08 → 2006-01-04 (+27d) |  |  | 20d → 6d | baseline start none → 2006-01-04; baseline finish none → 2006-01-04 |
| 211 | full system testing in prep for 'deep' ROV dive and cold water | 2005-12-08 → 2006-01-04 (+27d) | 2005-12-08 → 2006-01-04 (+27d) |  |  | 20d → 6d | baseline start none → 2006-01-04; baseline finish none → 2006-01-04 |
| 212 | Deploy D-ESP on ROV - 2, 1day dives (2mobs) | 2005-12-08 → 2006-01-04 (+27d) | 2005-12-08 → 2006-01-04 (+27d) |  |  | 20d → 6d | baseline start none → 2006-01-04; baseline finish none → 2006-01-04 |
| 213 | **MARS interface** | 2005-12-08 → 2006-01-04 (+27d) | 2005-12-08 → 2006-01-04 (+27d) |  |  | 20d → 6d | baseline start none → 2006-01-04; baseline finish none → 2006-01-04 |
| 214 | Power Supply | 2005-12-08 → 2006-01-04 (+27d) | 2005-12-08 → 2006-01-04 (+27d) |  |  | 20d → 6d | baseline start none → 2006-01-04; baseline finish none → 2006-01-04 |
| 215 | Communications interface | 2005-12-08 → 2006-01-04 (+27d) | 2005-12-08 → 2006-01-04 (+27d) |  |  | 20d → 6d | baseline start none → 2006-01-04; baseline finish none → 2006-01-04 |
| 216 | deployment structure | 2005-12-08 → 2006-01-04 (+27d) | 2005-12-08 → 2006-01-04 (+27d) |  |  | 20d → 6d | baseline start none → 2006-01-04; baseline finish none → 2006-01-04 |
| 217 | mob for MARS | 2005-12-08 → 2006-01-04 (+27d) | 2005-12-08 → 2006-01-04 (+27d) |  |  | 20d → 6d | baseline start none → 2006-01-04; baseline finish none → 2006-01-04 |
| 218 | contingency/support | 2005-12-08 → 2006-01-04 (+27d) | 2005-12-08 → 2006-01-04 (+27d) |  |  | 20d → 6d | baseline start none → 2006-01-04; baseline finish none → 2006-01-04 |
| 219 | MARS deployment | 2005-12-08 → 2006-01-04 (+27d) | 2005-12-08 → 2006-01-04 (+27d) |  |  | 20d → 6d | baseline start none → 2006-01-04; baseline finish none → 2006-01-04 |
| 221 | **NASA ASTEP** | 2005-12-08 → 2006-01-04 (+27d) | 2005-12-08 → 2006-01-04 (+27d) |  |  | 20d → 6d | baseline start none → 2006-01-04; baseline finish none → 2006-01-04 |
| 222 | system spec project start | 2005-12-08 → 2006-01-04 (+27d) | 2005-12-08 → 2006-01-04 (+27d) |  |  | 20d → 6d | baseline start none → 2006-01-04; baseline finish none → 2006-01-04 |
| 223 | analytical mod incorp (assumes LLNL subcontract funded - PCR) | 2005-12-08 → 2006-01-04 (+27d) | 2005-12-08 → 2006-01-04 (+27d) |  |  | 20d → 6d | baseline start none → 2006-01-04; baseline finish none → 2006-01-04 |
| 224 | ISUS context sensor incorp | 2005-12-08 → 2006-01-04 (+27d) | 2005-12-08 → 2006-01-04 (+27d) |  |  | 20d → 6d | baseline start none → 2006-01-04; baseline finish none → 2006-01-04 |
| 225 | modify/fab DWSM | 2005-12-08 → 2006-01-04 (+27d) | 2005-12-08 → 2006-01-04 (+27d) |  |  | 20d → 6d | baseline start none → 2006-01-04; baseline finish none → 2006-01-04 |
| 226 | Modify/fab 2G | 2005-12-08 → 2006-01-04 (+27d) | 2005-12-08 → 2006-01-04 (+27d) |  |  | 20d → 6d | baseline start none → 2006-01-04; baseline finish none → 2006-01-04 |
| 227 | design/fab pressure housing | 2005-12-08 → 2006-01-04 (+27d) | 2005-12-08 → 2006-01-04 (+27d) |  |  | 20d → 6d | baseline start none → 2006-01-04; baseline finish none → 2006-01-04 |
| 228 | design/fab benthic mooring structure | 2005-12-08 → 2006-01-04 (+27d) | 2005-12-08 → 2006-01-04 (+27d) |  |  | 20d → 6d | baseline start none → 2006-01-04; baseline finish none → 2006-01-04 |
| 229 | MOOS/MARS interface (may not be needed if internal funded) | 2005-12-08 → 2006-01-04 (+27d) | 2005-12-08 → 2006-01-04 (+27d) |  |  | 20d → 6d | baseline start none → 2006-01-04; baseline finish none → 2006-01-04 |
| 230 | Santa Monica Basin cruise? | 2005-12-08 → 2006-01-04 (+27d) | 2005-12-08 → 2006-01-04 (+27d) |  |  | 20d → 6d | baseline start none → 2006-01-04; baseline finish none → 2006-01-04 |
| 232 | **Moore Foundation** | 2005-12-08 → 2006-01-04 (+27d) | 2005-12-08 → 2006-01-04 (+27d) |  |  | 20d → 6d | baseline start none → 2006-01-04; baseline finish none → 2006-01-04 |
| 233 | define functional requirements (w/ Zehr) - system concept devel | 2005-12-08 → 2006-01-04 (+27d) | 2005-12-08 → 2006-01-04 (+27d) |  |  | 20d → 6d | baseline start none → 2006-01-04; baseline finish none → 2006-01-04 |
| 234 | evaluate existing analytical modules - candidacy | 2005-12-08 → 2006-01-04 (+27d) | 2005-12-08 → 2006-01-04 (+27d) |  |  | 20d → 6d | baseline start none → 2006-01-04; baseline finish none → 2006-01-04 |
| 235 | downselect candidate modules - develop test plan | 2005-12-08 → 2006-01-04 (+27d) | 2005-12-08 → 2006-01-04 (+27d) |  |  | 20d → 6d | baseline start none → 2006-01-04; baseline finish none → 2006-01-04 |
| 236 | develop lab test fixture that incorps elements of ESP and analytical modules | 2005-12-08 → 2006-01-04 (+27d) | 2005-12-08 → 2006-01-04 (+27d) |  |  | 20d → 6d | baseline start none → 2006-01-04; baseline finish none → 2006-01-04 |

## Version 3 (saved 2006-01-25, file ESP schedule 1_25_06.mpp)

Last finish 2006-01-12 → 2006-12-04 (+326d). Complete tasks 2 → 19.

Added:

| ID | Task | Duration | Start | Finish | Predecessors | Constraint | Resources |
| --- | --- | --- | --- | --- | --- | --- | --- |
| 26 | ME tech | 1d? | 2006-01-04 A | 2006-01-04 A |  |  |  |
| 28 | shop | 1d? | 2006-01-04 A | 2006-01-04 A |  |  |  |
| 30 | ME tech | 1d? | 2006-01-04 A | 2006-01-04 A |  |  |  |
| 32 | shop | 1d? | 2006-01-04 A | 2006-01-04 A |  |  |  |
| 46 | **Fabricate** | 1d? | 2006-01-04 | 2006-01-04 |  |  |  |
| 49 | ME Tech | 1d? | 2006-01-04 | 2006-01-04 |  |  |  |
| 50 | EE Tech | 1d? | 2006-01-04 | 2006-01-04 |  |  |  |
| 56 | ME Tech | 1d? | 2006-01-04 | 2006-01-04 |  |  |  |
| 58 | **Software** | 40d | 2006-01-04 | 2006-02-28 |  |  |  |
| 59 | **Contextual Sensors** | 30d | 2006-01-04 | 2006-02-14 |  |  |  |
| 61 | External SE | 30d | 2006-01-04 | 2006-02-14 |  |  | Bob |
| 62 | Power cycling | 25d | 2006-01-25 | 2006-02-28 |  | start no earlier than 2006-01-25 | Brent [60%] |
| 69 | **Fabricate** | 1d? | 2006-01-04 | 2006-01-04 |  |  |  |
| 72 | ME Tech | 1d? | 2006-01-04 | 2006-01-04 |  |  |  |
| 73 | EE Tech | 1d? | 2006-01-04 | 2006-01-04 |  |  |  |
| 79 | ME Tech | 1d? | 2006-01-04 | 2006-01-04 |  |  |  |
| 90 | Outside fab | 25d | 2006-02-06 | 2006-03-10 |  |  |  |
| 91 | ME tech | 2d | 2006-02-06 | 2006-02-07 |  |  |  |
| 93 | ME tech | 2d | 2006-03-13 | 2006-03-14 |  |  |  |
| 97 | **MOB resources** | 1d? | 2006-03-08 | 2006-03-08 | 96SS |  |  |
| 101 | **Deployment resources** | 13d? | 2006-03-09 | 2006-03-27 |  |  |  |
| 105 | **Recover** | 2d | 2006-03-24 | 2006-03-27 |  |  |  |
| 109 | MOB | 1d | 2006-04-03 | 2006-04-03 | 113SS | start no earlier than 2006-03-08 |  |
| 113 | Deployment | 16d | 2006-04-03 | 2006-04-24 |  | finish no earlier than 2006-04-24 |  |
| 114 | **Deployment resources** | 16d? | 2006-04-03 | 2006-04-24 |  |  |  |
| 118 | **Recover** | 2d | 2006-04-21 | 2006-04-24 |  |  |  |
| 122 | MOB | 1d | 2006-05-01 | 2006-05-01 | 125SS | start no earlier than 2006-03-08 |  |
| 123 | **MOB resources** | 1d? | 2006-05-01 | 2006-05-01 | 122SS |  |  |
| 125 | Deployment | 10d | 2006-05-01 | 2006-05-12 |  | start no earlier than 2006-05-01 |  |
| 126 | **Deployment resources** | 10d? | 2006-05-01 | 2006-05-12 |  |  |  |
| 127 | **Deploy** | 1d? | 2006-05-01 | 2006-05-01 | 125SS |  |  |
| 129 | **Recover** | 2d | 2006-05-11 | 2006-05-12 |  |  |  |
| 132 | MOB | 1d | 2006-05-30 | 2006-05-30 | 135SS | start no earlier than 2006-03-08 |  |
| 133 | **MOB resources** | 1d? | 2006-05-30 | 2006-05-30 | 132SS |  |  |
| 135 | Deployment | 20d | 2006-05-30 | 2006-06-26 |  | start no earlier than 2006-05-30 |  |
| 136 | **Deployment resources** | 20d? | 2006-05-30 | 2006-06-26 |  |  |  |
| 137 | **Deploy** | 1d? | 2006-05-30 | 2006-05-30 | 135SS |  |  |
| 139 | **Recover** | 2d | 2006-06-23 | 2006-06-26 |  |  |  |
| 142 | MOB | 1d | 2006-07-05 | 2006-07-05 | 145SS | start no earlier than 2006-03-08 |  |
| 143 | **MOB resources** | 1d? | 2006-07-05 | 2006-07-05 | 142SS |  |  |
| 145 | Deployment | 14d | 2006-07-05 | 2006-07-24 |  | start no earlier than 2006-07-05 |  |
| 146 | **Deployment resources** | 14d? | 2006-07-05 | 2006-07-24 |  |  |  |
| 147 | **Deploy** | 1d? | 2006-07-05 | 2006-07-05 | 145SS |  |  |
| 149 | **Recover** | 2d | 2006-07-21 | 2006-07-24 |  |  |  |
| 152 | MOB | 1d | 2006-09-08 | 2006-09-08 | 155SS | start no earlier than 2006-03-08 |  |
| 153 | **MOB resources** | 1d? | 2006-09-08 | 2006-09-08 | 152SS |  |  |
| 154 | EE | 1d? | 2006-09-08 | 2006-09-08 |  |  |  |
| 155 | Deployment | 17d | 2006-09-08 | 2006-10-02 |  | start no earlier than 2006-09-08 |  |
| 156 | **Deployment resources** | 17d? | 2006-09-08 | 2006-10-02 |  |  |  |
| 157 | **Deploy** | 1d? | 2006-09-08 | 2006-09-08 | 155SS |  |  |
| 158 | EE | 1d? | 2006-09-08 | 2006-09-08 |  |  |  |
| 159 | **Recover** | 2d | 2006-09-29 | 2006-10-02 |  |  |  |
| 160 | EE | 2d | 2006-09-29 | 2006-10-02 | 155FF |  |  |
| 161 | **Deployment contingency** | 2d | 2006-09-29 | 2006-10-02 |  |  |  |
| 162 | EE | 2d | 2006-09-29 | 2006-10-02 | 96SS | finish no earlier than 2006-10-02 |  |
| 165 | ME Tech | 2d | 2006-09-29 | 2006-10-02 | 96SS | finish no earlier than 2006-10-02 |  |
| 166 | EE Tech | 2d | 2006-09-29 | 2006-10-02 | 96SS | finish no earlier than 2006-10-02 |  |
| 170 | **Copy Resources** | 1d? | 2006-06-05 | 2006-06-05 |  |  |  |
| 171 | EE | 1d? | 2006-06-05 | 2006-06-05 | 169SS |  |  |
| 174 | ME Tech | 1d? | 2006-06-05 | 2006-06-05 | 169SS |  |  |
| 175 | EE Tech | 1d? | 2006-06-05 | 2006-06-05 | 169SS |  |  |
| 178 | **workshop Resources** | 1d? | 2006-12-04 | 2006-12-04 |  |  |  |
| 179 | EE | 1d? | 2006-12-04 | 2006-12-04 | 177SS | start no earlier than 2006-12-04 |  |
| 186 | **DWSM Benchtop I&T** | 50d | 2006-01-04 | 2006-03-14 |  |  |  |
| 187 | EE | 6d | 2006-01-04 | 2006-01-11 |  |  | Scott [50%] |
| 191 | **DWSM Coldroom testing** | 4d | 2006-03-15 | 2006-03-20 | 186 |  |  |
| 192 | EE | 4d | 2006-03-15 | 2006-03-20 |  |  | Scott [50%] |
| 195 | **DWSM ROV test** | 9d | 2006-03-21 | 2006-03-31 | 191 |  |  |
| 196 | EE | 9d | 2006-03-21 | 2006-03-31 |  |  | Scott [33.3%] |
| 199 | **D-ESP Benchtop I&T** | 1d? | 2006-04-03 | 2006-04-03 | 195 |  |  |
| 200 | EE | 1d? | 2006-04-03 | 2006-04-03 |  |  | Scott |
| 201 | ME | 1d? | 2006-04-03 | 2006-04-03 |  |  |  |
| 203 | **D-ESP Coldroom testing** | 1d? | 2006-04-04 | 2006-04-04 | 199 |  |  |
| 204 | EE | 1d? | 2006-04-04 | 2006-04-04 |  |  | Scott |
| 205 | ME | 1d? | 2006-04-04 | 2006-04-04 |  |  |  |
| 207 | **D-ESP Tank Test** | 1d? | 2006-04-05 | 2006-04-05 | 203 |  |  |
| 208 | EE | 1d? | 2006-04-05 | 2006-04-05 |  |  | Scott |
| 209 | ME | 1d? | 2006-04-05 | 2006-04-05 |  |  |  |
| 211 | **D-ESP ROV test** | 2d? | 2006-04-06 | 2006-04-07 | 207 |  |  |
| 212 | EE | 2d? | 2006-04-06 | 2006-04-07 |  |  | Scott |
| 213 | ME | 1d? | 2006-04-06 | 2006-04-06 |  |  |  |
| 216 | **Deployment 1** | 176d? | 2006-01-04 | 2006-09-06 |  |  |  |
| 217 | MOB | 1d? | 2006-01-04 | 2006-01-04 |  |  |  |
| 218 | **MOB resources** | 176d? | 2006-01-04 | 2006-09-06 |  |  |  |
| 219 | EE | 1d? | 2006-01-04 | 2006-01-04 |  |  |  |
| 220 | ME | 1d? | 2006-01-04 | 2006-01-04 |  |  |  |
| 221 | ME Tech | 1d? | 2006-01-04 | 2006-01-04 |  |  |  |
| 222 | Deployment | 1d? | 2006-09-06 | 2006-09-06 |  | start no earlier than 2006-09-06 |  |
| 224 | EE | 1d? | 2006-01-04 | 2006-01-04 |  |  |  |
| 225 | ME | 1d? | 2006-01-04 | 2006-01-04 |  |  |  |
| 226 | **Deployment 2** | 187d? | 2006-01-04 | 2006-09-21 |  |  |  |
| 227 | MOB | 1d? | 2006-01-04 | 2006-01-04 |  |  |  |
| 228 | **MOB resources** | 187d? | 2006-01-04 | 2006-09-21 |  |  |  |
| 229 | EE | 1d? | 2006-01-04 | 2006-01-04 |  |  |  |
| 230 | ME | 1d? | 2006-01-04 | 2006-01-04 |  |  |  |
| 231 | ME Tech | 1d? | 2006-01-04 | 2006-01-04 |  |  |  |
| 232 | Deplyment | 1d? | 2006-09-21 | 2006-09-21 |  | start no earlier than 2006-09-21 |  |
| 234 | EE | 1d? | 2006-01-04 | 2006-01-04 |  |  |  |
| 235 | ME | 1d? | 2006-01-04 | 2006-01-04 |  |  |  |
| 238 | EE | 1d? | 2006-01-04 | 2006-01-04 |  |  |  |
| 239 | ME | 1d? | 2006-01-04 | 2006-01-04 |  |  |  |
| 241 | ME Tech | 1d? | 2006-01-04 | 2006-01-04 |  |  |  |
| 243 | ME | 1d? | 2006-01-04 | 2006-01-04 |  |  |  |
| 244 | ME Tech | 1d? | 2006-01-04 | 2006-01-04 |  |  |  |
| 247 | MOB | 1d? | 2006-11-03 | 2006-11-03 |  | start no earlier than 2006-11-03 |  |
| 249 | EE | 1d? | 2006-01-04 | 2006-01-04 |  |  |  |
| 250 | ME | 1d? | 2006-01-04 | 2006-01-04 |  |  |  |
| 252 | ME Tech | 1d? | 2006-01-04 | 2006-01-04 |  |  |  |
| 253 | EE Tech | 1d? | 2006-01-04 | 2006-01-04 |  |  |  |
| 255 | Deployment | 21d? | 2006-11-06 | 2006-12-04 |  | finish no earlier than 2006-12-04 |  |
| 256 | **contingency/support** | 1d? | 2006-01-04 | 2006-01-04 |  |  |  |
| 257 | EE | 1d? | 2006-01-04 | 2006-01-04 |  |  |  |
| 258 | ME | 1d? | 2006-01-04 | 2006-01-04 |  |  |  |
| 260 | ME Tech | 1d? | 2006-01-04 | 2006-01-04 |  |  |  |
| 261 | EE Tech | 1d? | 2006-01-04 | 2006-01-04 |  |  |  |
| 268 | EE | 1d? | 2006-01-04 | 2006-01-04 |  |  |  |
| 269 | ME | 1d? | 2006-01-04 | 2006-01-04 |  |  |  |
| 272 | Sci | 1d? | 2006-01-04 | 2006-01-04 |  |  |  |
| 274 | EE | 1d? | 2006-01-04 | 2006-01-04 |  |  |  |
| 275 | ME | 1d? | 2006-01-04 | 2006-01-04 |  |  |  |
| 278 | Sci | 1d? | 2006-01-04 | 2006-01-04 |  |  |  |
| 279 | Sci Tech | 1d? | 2006-01-04 | 2006-01-04 |  |  |  |
| 280 | EE | 1d? | 2006-01-04 | 2006-01-04 |  |  |  |
| 281 | ME | 1d? | 2006-01-04 | 2006-01-04 |  |  |  |
| 282 | SE | 1d? | 2006-01-04 | 2006-01-04 |  |  |  |
| 284 | Sci | 1d? | 2006-01-04 | 2006-01-04 |  |  |  |
| 285 | Sci Tech | 1d? | 2006-01-04 | 2006-01-04 |  |  |  |
| 286 | EE | 1d? | 2006-01-04 | 2006-01-04 |  |  |  |
| 287 | ME | 1d? | 2006-01-04 | 2006-01-04 |  |  |  |
| 288 | SE | 1d? | 2006-01-04 | 2006-01-04 |  |  |  |
| 289 | ME Tech | 1d? | 2006-01-04 | 2006-01-04 |  |  |  |
| 292 | Sci | 1d? | 2006-01-04 | 2006-01-04 |  |  |  |
| 293 | Sci Tech | 1d? | 2006-01-04 | 2006-01-04 |  |  |  |
| 294 | EE | 1d? | 2006-01-04 | 2006-01-04 |  |  |  |
| 295 | ME | 1d? | 2006-01-04 | 2006-01-04 |  |  |  |
| 296 | SE | 1d? | 2006-01-04 | 2006-01-04 |  |  |  |
| 297 | ME Tech | 1d? | 2006-01-04 | 2006-01-04 |  |  |  |
| 298 | EE Tech | 1d? | 2006-01-04 | 2006-01-04 |  |  |  |
| 301 | Sci | 1d? | 2006-01-04 | 2006-01-04 |  |  |  |
| 302 | Sci Tech | 1d? | 2006-01-04 | 2006-01-04 |  |  |  |
| 303 | EE | 1d? | 2006-01-04 | 2006-01-04 |  |  |  |
| 304 | ME | 1d? | 2006-01-04 | 2006-01-04 |  |  |  |
| 305 | ME Tech | 1d? | 2006-01-04 | 2006-01-04 |  |  |  |
| 306 | EE Tech | 1d? | 2006-01-04 | 2006-01-04 |  |  |  |
| 309 | Sci | 1d? | 2006-01-04 | 2006-01-04 |  |  |  |
| 310 | Sci Tech | 1d? | 2006-01-04 | 2006-01-04 |  |  |  |
| 311 | EE | 1d? | 2006-01-04 | 2006-01-04 |  |  |  |
| 312 | ME | 1d? | 2006-01-04 | 2006-01-04 |  |  |  |
| 313 | ME Tech | 1d? | 2006-01-04 | 2006-01-04 |  |  |  |
| 314 | EE Tech | 1d? | 2006-01-04 | 2006-01-04 |  |  |  |
| 317 | Sci | 1d? | 2006-01-04 | 2006-01-04 |  |  |  |
| 318 | Sci Tech | 1d? | 2006-01-04 | 2006-01-04 |  |  |  |
| 319 | EE | 1d? | 2006-01-04 | 2006-01-04 |  |  |  |
| 320 | ME | 1d? | 2006-01-04 | 2006-01-04 |  |  |  |
| 321 | SE | 1d? | 2006-01-04 | 2006-01-04 |  |  |  |
| 322 | ME Tech | 1d? | 2006-01-04 | 2006-01-04 |  |  |  |
| 323 | EE Tech | 1d? | 2006-01-04 | 2006-01-04 |  |  |  |
| 328 | Sci | 1d? | 2006-01-04 | 2006-01-04 |  |  |  |
| 329 | EE | 1d? | 2006-01-04 | 2006-01-04 |  |  |  |
| 330 | ME | 1d? | 2006-01-04 | 2006-01-04 |  |  |  |
| 331 | SE | 1d? | 2006-01-04 | 2006-01-04 |  |  |  |
| 333 | Sci | 1d? | 2006-01-04 | 2006-01-04 |  |  |  |
| 334 | EE | 1d? | 2006-01-04 | 2006-01-04 |  |  |  |
| 335 | ME | 1d? | 2006-01-04 | 2006-01-04 |  |  |  |
| 336 | SE | 1d? | 2006-01-04 | 2006-01-04 |  |  |  |
| 338 | Sci | 1d? | 2006-01-04 | 2006-01-04 |  |  |  |
| 339 | EE | 1d? | 2006-01-04 | 2006-01-04 |  |  |  |
| 340 | ME | 1d? | 2006-01-04 | 2006-01-04 |  |  |  |
| 341 | SE | 1d? | 2006-01-04 | 2006-01-04 |  |  |  |
| 343 | Sci | 1d? | 2006-01-04 | 2006-01-04 |  |  |  |
| 344 | EE | 1d? | 2006-01-04 | 2006-01-04 |  |  |  |
| 345 | ME | 1d? | 2006-01-04 | 2006-01-04 |  |  |  |
| 346 | SE | 1d? | 2006-01-04 | 2006-01-04 |  |  |  |
| 347 | ME Tech | 1d? | 2006-01-04 | 2006-01-04 |  |  |  |
| 348 | EE Tech | 1d? | 2006-01-04 | 2006-01-04 |  |  |  |

Removed: 35 Drawing package update; 42 METech; 45 fabricate; 49 METech; 50 EETech; 56 METech; 57 EETech; 65 METech; 66 EETech; 68 fabricate; 72 METech; 73 EETech; 79 METech; 80 EETech; 94 EETech; 101 EETech; 107 METech; 108 EETech; 117 METech; 118 EETech; 124 METech; 125 EETech; 132 METech; 133 EETech; 139 METech; 140 EETech; 143 MOB; 147 METech; 148 EETech; 149 Shop; 154 METech; 155 EETech; 156 Shop; 158 MOB; 162 METech; 163 EETech; 164 Shop; 165 Deployment; 169 METech; 170 EETech; 171 Shop; 173 MOB; 177 METech; 178 EETech; 179 Shop; 180 Deployment; 184 METech; 185 EETech; 186 Shop; 188 MOB; 192 METech; 193 EETech; 194 Shop; 195 Deployment; 199 METech; 200 EETech; 201 Shop; 210 DWSM; 211 full system testing in prep for 'deep' ROV dive and cold water; 215 Communications interface; 217 mob for MARS; 218 contingency/support; 229 MOOS/MARS interface (may not be needed if internal funded)

Changed:

| ID | Task | Start | Finish | Duration | Complete | Total float | Predecessors | Other |
| --- | --- | --- | --- | --- | --- | --- | --- | --- |
| 1 | **GiGi core** |  | 2006-01-12 → 2006-02-28 (+47d) | 22d? → 55d? | 1% → 14% | 0d → 199d |  |  |
| 4 | **Refit system valves to Cheminert valves** |  | 2006-01-04 → 2006-02-07 (+34d) | 15d → 40d? | 99% → 41% | 7d → 214d |  |  |
| 6 | Split cost of valves | 2006-01-04 A → 2006-01-04 | 2006-01-04 A → 2006-01-04 |  | 100% → 0% | none → 239d |  | baseline start 2006-01-04 → none; baseline finish 2006-01-04 → none |
| 8 | **Valve bracket redesign** | 2006-01-04 A | 2006-01-05 A |  | 0% → 100% | 5d → none |  |  |
| 9 | **Design** | 2006-01-04 A | 2006-01-05 A |  | 0% → 100% | 5d → none |  |  |
| 10 | EE | 2006-01-04 A | 2006-01-05 A |  | 0% → 100% | 5.57d → none |  |  |
| 11 | ME | 2006-01-04 A | 2006-01-05 A |  | 0% → 100% | 5d → none |  |  |
| 12 | SE | 2006-01-04 A | 2006-01-05 A |  | 0% → 100% | 5.57d → none |  |  |
| 13 | **Part procurment** | 2006-01-04 A | 2006-01-05 A |  | 0% → 100% | 5d → none |  |  |
| 14 | ME Tech | 2006-01-04 A | 2006-01-04 A |  | 0% → 100% | 6d → none |  | baseline start 2006-01-04 → none; baseline finish 2006-01-04 → none |
| 15 | ME | 2006-01-04 A | 2006-01-05 A |  | 0% → 100% | 5d → none |  |  |
| 16 | **fabrication** | 2006-01-04 A | 2006-01-04 A |  | 0% → 100% | 6d → none |  |  |
| 17 | METech | 2006-01-04 A | 2006-01-04 A |  | 0% → 100% | 6d → none |  | baseline start 2006-01-04 → none; baseline finish 2006-01-04 → none |
| 18 | ME | 2006-01-04 A | 2006-01-04 A |  | 0% → 100% | 6d → none |  | baseline start 2006-01-04 → none; baseline finish 2006-01-04 → none |
| 19 | EE | 2006-01-04 A | 2006-01-04 A |  | 0% → 100% | 6d → none |  | baseline start 2006-01-04 → none; baseline finish 2006-01-04 → none |
| 20 | **Assembly** | 2006-01-04 A | 2006-01-04 A |  | 0% → 100% | 6d → none |  |  |
| 21 | ME Tech | 2006-01-04 A | 2006-01-04 A |  | 0% → 100% | 6d → none |  | baseline start 2006-01-04 → none; baseline finish 2006-01-04 → none |
| 22 | **Valve placement in instrument** | 2006-01-04 A |  |  | 0% → 90% | 6d → 238d |  |  |
| 23 | Physical modelling for valve placement | 2006-01-04 A | 2006-01-04 A |  | 0% → 100% | 6d → none |  |  |
| 24 | **Instrument modifications** | 2006-01-04 A | 2006-01-04 A |  | 0% → 100% | 6d → none |  |  |
| 25 | **Fabrication** | 2006-01-04 A | 2006-01-04 A |  | 0% → 100% | 6d → none |  |  |
| 27 | ME | 2006-01-04 A | 2006-01-12 → 2006-01-04 A (-8d) | 7d? → 1d? | 0% → 100% | 0d → none |  | resources Gene → none; baseline start 2006-01-04 → none; baseline finish 2006-01-12 → none |
| 29 | **assembly** | 2006-01-04 A | 2006-01-04 A |  | 0% → 100% | 6d → none |  |  |
| 31 | ME | 2006-01-04 A | 2006-01-04 A |  | 0% → 100% | 6d → none |  | baseline start 2006-01-04 → none; baseline finish 2006-01-04 → none |
| 33 | EE | 2006-01-04 A | 2006-01-04 A |  | 0% → 100% | 6d → none |  | resources Scott → none; baseline start 2006-01-04 → none; baseline finish 2006-01-04 → none |
| 34 | SE | 2006-01-04 A | 2006-01-05 → 2006-01-04 A (-1d) | 2d? → 1d? | 0% → 100% | 5d → none |  | resources Brent → none; baseline start 2006-01-04 → none; baseline finish 2006-01-05 → none |
| 36 | EE |  |  |  |  | 6d → 238d |  | resources Scott → none; baseline start 2006-01-04 → none; baseline finish 2006-01-04 → none |
| 37 | Protocol redevelopment | 2006-01-04 → 2006-01-25 (+21d) | 2006-01-04 → 2006-02-07 (+34d) | 1d? → 10d |  | 6d → 214d |  | constraint none → start no earlier than 2006-01-25; resources none → Science Team |
| 38 | **Refit completion** |  | 2006-01-04 → 2006-01-31 (+27d) | 1d? → 20d? |  | 6d → 219d |  |  |
| 39 | Model and drawing update - MB |  | 2006-01-04 → 2006-01-31 (+27d) | 1d? → 20d? |  | 6d → 219d |  | was named Model update; resources Mark B → Mark Brown [20%] |
| 41 | **modify bulkhead valves - eliminate solenoid** |  | 2006-01-12 → 2006-01-04 (-8d) | 7d? → 1d? |  | 0d → 238d |  |  |
| 42 | **design** |  | 2006-01-12 → 2006-01-04 (-8d) | 7d? → 1d? |  | 0d → 238d |  |  |
| 43 | EE |  | 2006-01-10 → 2006-01-04 (-6d) | 5d? → 1d? |  | 2d → 238d |  | resources Scott → none; baseline start 2006-01-04 → none; baseline finish 2006-01-10 → none |
| 44 | ME |  |  |  |  | 6d → 238d |  | baseline start 2006-01-04 → none; baseline finish 2006-01-04 → none |
| 45 | SE |  |  |  |  | 6d → 238d |  | baseline start 2006-01-04 → none; baseline finish 2006-01-04 → none |
| 47 | EE |  |  |  |  | 6d → 238d |  | baseline start 2006-01-04 → none; baseline finish 2006-01-04 → none |
| 48 | ME |  |  |  |  | 6d → 238d |  | baseline start 2006-01-04 → none; baseline finish 2006-01-04 → none |
| 53 | EE |  |  |  |  | 6d → 238d |  | baseline start 2006-01-04 → none; baseline finish 2006-01-04 → none |
| 54 | ME |  |  |  |  | 6d → 238d |  | baseline start 2006-01-04 → none; baseline finish 2006-01-04 → none |
| 55 | SE |  |  |  |  | 6d → 238d |  | baseline start 2006-01-04 → none; baseline finish 2006-01-04 → none |
| 60 | SE |  | 2006-01-04 → 2006-02-14 (+41d) | 1d? → 30d |  | 6d → 209d |  | resources none → Brent [16.7%]; baseline start 2006-01-04 → none; baseline finish 2006-01-04 → none |
| 66 | EE |  |  |  |  | 6d → 238d |  | baseline start 2006-01-04 → none; baseline finish 2006-01-04 → none |
| 67 | ME |  |  |  |  | 6d → 238d |  | baseline start 2006-01-04 → none; baseline finish 2006-01-04 → none |
| 68 | SE |  |  |  |  | 6d → 238d |  | baseline start 2006-01-04 → none; baseline finish 2006-01-04 → none |
| 70 | EE |  |  |  |  | 6d → 238d |  | baseline start 2006-01-04 → none; baseline finish 2006-01-04 → none |
| 71 | ME |  |  |  |  | 6d → 238d |  | baseline start 2006-01-04 → none; baseline finish 2006-01-04 → none |
| 76 | EE |  |  |  |  | 6d → 238d |  | baseline start 2006-01-04 → none; baseline finish 2006-01-04 → none |
| 77 | ME |  |  |  |  | 6d → 238d |  | baseline start 2006-01-04 → none; baseline finish 2006-01-04 → none |
| 78 | SE |  |  |  |  | 6d → 238d |  | baseline start 2006-01-04 → none; baseline finish 2006-01-04 → none |
| 83 | annimator |  |  |  |  | 6d → 238d |  | resources Brent [3500%] → none |
| 85 | **Finish surface surface water housing for GiGi** | 2006-01-04 → 2006-01-25 (+21d) | 2006-01-04 → 2006-03-14 (+69d) | 1d? → 35d |  | 6d → 189d |  | was named Finish surface surface water GiGi |
| 86 | **Pressure housing for GiGi - surface water - 50m** | 2006-01-04 → 2006-01-25 (+21d) | 2006-01-04 → 2006-03-14 (+69d) | 1d? → 35d |  | 6d → 189d |  |  |
| 87 | **Design** | 2006-01-04 → 2006-01-25 (+21d) | 2006-01-04 → 2006-02-03 (+30d) | 1d? → 8d |  | 6d → 189d |  |  |
| 88 | ME | 2006-01-05 → 2006-01-25 (+20d) | 2006-01-05 → 2006-02-03 (+29d) | 1d? → 8d |  | 5d → 189d |  | constraint none → start no earlier than 2006-01-25; resources none → Gene [12.5%]; baseline start 2006-01-05 → none; baseline finish 2006-01-05 → none |
| 89 | **assembly** | 2006-01-04 → 2006-02-06 (+33d) | 2006-01-04 → 2006-03-10 (+65d) | 1d? → 25d |  | 6d → 189d | none → 87 |  |
| 92 | **Pressure test** | 2006-01-04 → 2006-03-13 (+68d) | 2006-01-04 → 2006-03-14 (+69d) | 1d? → 2d |  | 6d → 189d | none → 89 | was named test (if not sent to NFESC - naval facl eng supp center alt ~ $2.5K |
| 94 | **Shallow water deployments** | 2006-01-04 → 2006-03-08 (+63d) | 2006-01-12 → 2006-10-02 (+263d) | 7d? → 149d? |  | 0d → 45d |  |  |
| 95 | **Deployment 1** | 2006-01-04 → 2006-03-08 (+63d) | 2006-01-05 → 2006-03-27 (+81d) | 2d? → 14d? |  | 5d → 180d |  |  |
| 96 | MOB | 2006-01-04 → 2006-03-08 (+63d) | 2006-01-04 → 2006-03-09 (+64d) |  |  | 5d → 192d | none → 100SF | constraint none → start no earlier than 2006-03-08 |
| 98 | EE | 2006-01-04 → 2006-03-08 (+63d) | 2006-01-04 → 2006-03-08 (+63d) |  |  | 6d → 193d |  | baseline start 2006-01-04 → none; baseline finish 2006-01-04 → none |
| 99 | ME | 2006-01-05 → 2006-03-08 (+62d) | 2006-01-05 → 2006-03-08 (+62d) |  |  | 0d → 193d | 119 → none | baseline start 2006-01-05 → none; baseline finish 2006-01-05 → none |
| 100 | Deployment | 2006-01-05 → 2006-03-09 (+63d) | 2006-01-05 → 2006-03-27 (+81d) | 1d? → 13d |  | 5d → 180d | 96 → none | constraint none → start no earlier than 2006-03-09 |
| 102 | **Deploy** | 2006-01-04 → 2006-03-09 (+64d) | 2006-01-04 → 2006-03-09 (+64d) |  |  | 6d → 192d | none → 100SS | was named EETech; baseline start 2006-01-04 → none; baseline finish 2006-01-04 → none |
| 103 | EE | 2006-01-04 → 2006-03-09 (+64d) | 2006-01-04 → 2006-03-09 (+64d) |  |  | 6d → 192d |  | resources Scott → none; baseline start 2006-01-04 → none; baseline finish 2006-01-04 → none |
| 104 | ME | 2006-01-12 → 2006-03-09 (+56d) | 2006-01-12 → 2006-03-09 (+56d) |  |  | 0d → 192d |  | baseline start 2006-01-12 → none; baseline finish 2006-01-12 → none |
| 106 | EE | 2006-01-04 → 2006-03-24 (+79d) | 2006-01-04 → 2006-03-27 (+82d) | 1d? → 2d |  | 6d → 180d | none → 100FF | baseline start 2006-01-04 → none; baseline finish 2006-01-04 → none |
| 107 | ME | 2006-01-04 → 2006-03-24 (+79d) | 2006-01-04 → 2006-03-27 (+82d) | 1d? → 2d |  | 6d → 180d | none → 100FF | baseline start 2006-01-04 → none; baseline finish 2006-01-04 → none |
| 108 | **Deployment 2** | 2006-01-04 → 2006-04-03 (+89d) | 2006-01-12 → 2006-04-24 (+102d) | 7d? → 16d? |  | 0d → 160d |  | baseline finish 2006-01-04 → 2006-03-08 |
| 110 | **MOB resources** | 2006-01-04 → 2006-04-03 (+89d) | 2006-01-04 → 2006-04-03 (+89d) |  |  | 6d → 175d | none → 109SS | was named METech; baseline start 2006-01-04 → none; baseline finish 2006-01-04 → none |
| 111 | EE | 2006-01-05 → 2006-04-03 (+88d) | 2006-01-05 → 2006-04-03 (+88d) |  |  | 5d → 175d |  | baseline start 2006-01-05 → none; baseline finish 2006-01-05 → none |

| ID | Task | Start | Finish | Duration | Complete | Total float | Predecessors | Other |
| --- | --- | --- | --- | --- | --- | --- | --- | --- |
| 112 | ME | 2006-01-05 → 2006-04-03 (+88d) | 2006-01-05 → 2006-04-03 (+88d) |  |  | 0d → 175d | 128 → none | baseline start 2006-01-05 → none; baseline finish 2006-01-05 → none |
| 115 | **Deploy** | 2006-01-04 → 2006-04-03 (+89d) | 2006-01-04 → 2006-04-03 (+89d) |  |  | 6d → 175d | none → 113SS | was named METech; baseline start 2006-01-04 → none; baseline finish 2006-01-04 → none |
| 116 | EE | 2006-01-04 → 2006-04-03 (+89d) | 2006-01-04 → 2006-04-03 (+89d) |  |  | 6d → 175d |  | baseline start 2006-01-04 → none; baseline finish 2006-01-04 → none |
| 117 | ME | 2006-01-04 → 2006-04-03 (+89d) | 2006-01-04 → 2006-04-03 (+89d) |  |  | 6d → 175d |  | baseline start 2006-01-04 → none; baseline finish 2006-01-04 → none |
| 119 | EE | 2006-01-04 → 2006-04-21 (+107d) | 2006-01-04 → 2006-04-24 (+110d) | 1d? → 2d |  | 0d → 160d | none → 113FF | baseline start 2006-01-04 → none; baseline finish 2006-01-04 → none |
| 120 | ME | 2006-01-12 → 2006-04-21 (+99d) | 2006-01-12 → 2006-04-24 (+102d) | 1d? → 2d |  | 0d → 160d | none → 113FF | baseline start 2006-01-12 → none; baseline finish 2006-01-12 → none |
| 121 | **Deployment 3** | 2006-01-04 → 2006-05-01 (+117d) | 2006-01-12 → 2006-05-12 (+120d) | 7d? → 10d? |  | 0d → 146d |  |  |
| 124 | EE | 2006-01-12 → 2006-05-01 (+109d) | 2006-01-12 → 2006-05-01 (+109d) |  |  | 0d → 155d |  | baseline start 2006-01-12 → none; baseline finish 2006-01-12 → none |
| 128 | EE | 2006-01-04 → 2006-05-01 (+117d) | 2006-01-04 → 2006-05-01 (+117d) |  |  | 0d → 155d |  | baseline start 2006-01-04 → none; baseline finish 2006-01-04 → none |
| 130 | EE | 2006-01-12 → 2006-05-11 (+119d) | 2006-01-12 → 2006-05-12 (+120d) | 1d? → 2d |  | 0d → 146d | none → 125FF | baseline start 2006-01-12 → none; baseline finish 2006-01-12 → none |
| 131 | **Deployment 4** | 2006-01-04 → 2006-05-30 (+146d) | 2006-01-12 → 2006-06-26 (+165d) | 7d? → 20d? |  | 0d → 115d |  | baseline finish 2006-01-04 → 2006-03-08 |
| 134 | EE | 2006-01-04 → 2006-05-30 (+146d) | 2006-01-04 → 2006-05-30 (+146d) |  |  | 0d → 134d |  | baseline start 2006-01-04 → none; baseline finish 2006-01-04 → none |
| 138 | EE | 2006-01-12 → 2006-05-30 (+138d) | 2006-01-12 → 2006-05-30 (+138d) |  |  | 0d → 134d |  | baseline start 2006-01-12 → none; baseline finish 2006-01-12 → none |
| 140 | EE | 2006-01-04 → 2006-06-23 (+170d) | 2006-01-04 → 2006-06-26 (+173d) | 1d? → 2d |  | 0d → 115d | none → 135FF | baseline start 2006-01-04 → none; baseline finish 2006-01-04 → none |
| 141 | **Deployment 5** | 2006-01-04 → 2006-07-05 (+182d) | 2006-01-12 → 2006-07-24 (+193d) | 7d? → 14d? |  | 0d → 95d |  |  |
| 144 | EE | 2006-01-12 → 2006-07-05 (+174d) | 2006-01-12 → 2006-07-05 (+174d) |  |  | 0d → 108d |  | baseline start 2006-01-12 → none; baseline finish 2006-01-12 → none |
| 148 | EE | 2006-01-04 → 2006-07-05 (+182d) | 2006-01-04 → 2006-07-05 (+182d) |  |  | 0d → 108d |  | baseline start 2006-01-04 → none; baseline finish 2006-01-04 → none |
| 150 | EE | 2006-01-12 → 2006-07-21 (+190d) | 2006-01-12 → 2006-07-24 (+193d) | 1d? → 2d |  | 0d → 95d | none → 145FF | baseline start 2006-01-12 → none; baseline finish 2006-01-12 → none |
| 151 | **Deployment 6** | 2006-01-04 → 2006-09-08 (+247d) | 2006-01-12 → 2006-10-02 (+263d) | 7d? → 17d? |  | 0d → 45d |  | baseline finish 2006-01-04 → 2006-03-08 |
| 163 | ME | 2006-01-05 → 2006-09-29 (+267d) | 2006-01-05 → 2006-10-02 (+270d) | 1d? → 2d |  | 0d → 45d | 134 → 96SS | constraint none → finish no earlier than 2006-10-02; baseline start 2006-01-05 → none; baseline finish 2006-01-05 → none |
| 164 | SE | 2006-01-04 → 2006-09-29 (+268d) | 2006-01-04 → 2006-10-02 (+271d) | 1d? → 2d |  | 6d → 45d | none → 96SS | constraint none → finish no earlier than 2006-10-02; baseline start 2006-01-04 → none; baseline finish 2006-01-04 → none |
| 168 | **Tech xfer** |  | 2006-01-04 → 2006-12-04 (+334d) | 1d? → 239d? |  | 6d → 0d |  |  |
| 169 | Build 3 copies using exisiting design and spec, based on GiGi working | 2006-01-04 → 2006-06-05 (+152d) | 2006-01-04 → 2006-12-01 (+331d) | 1d? → 130d |  | 6d → 1d |  | constraint none → start no earlier than 2006-06-05 |
| 172 | ME | 2006-01-12 → 2006-06-05 (+144d) | 2006-01-12 → 2006-06-05 (+144d) |  |  | 0d → 130d | none → 169SS | baseline start 2006-01-12 → none; baseline finish 2006-01-12 → none |
| 173 | SE | 2006-01-04 → 2006-06-05 (+152d) | 2006-01-04 → 2006-06-05 (+152d) |  |  | 6d → 130d | none → 169SS | baseline start 2006-01-04 → none; baseline finish 2006-01-04 → none |
| 176 | Shop | 2006-01-04 → 2006-06-05 (+152d) | 2006-01-04 → 2006-06-05 (+152d) |  |  | 6d → 130d | none → 169SS | baseline start 2006-01-04 → none; baseline finish 2006-01-04 → none |
| 180 | ME | 2006-01-05 → 2006-12-04 (+333d) | 2006-01-05 → 2006-12-04 (+333d) |  |  |  | 140 → 177SS | constraint none → start no earlier than 2006-12-04; baseline start 2006-01-05 → none; baseline finish 2006-01-05 → none |
| 181 | SE | 2006-01-04 → 2006-12-04 (+334d) | 2006-01-04 → 2006-12-04 (+334d) |  |  | 6d → 0d | none → 177SS | constraint none → start no earlier than 2006-12-04; baseline start 2006-01-04 → none; baseline finish 2006-01-04 → none |
| 183 | **Deep water GiGI** | 2006-01-04 A | 2006-01-04 → 2006-12-04 (+334d) | 1d? → 239d? | 0% → 1% | 6d → 0d |  | was named Finish deep water GiGI design |
| 184 | **D-ESP system testing** | 2006-01-04 A | 2006-01-04 → 2006-04-07 (+93d) | 1d? → 68d? | 0% → 1% | 6d → 171d |  |  |
| 185 | 2G ESP valves and syringes in test fixture - 4C target | 2006-01-04 A |  |  | 0% → 75% | 6d → 238d |  |  |
| 188 | ME | 2006-01-12 → 2006-01-04 (-8d) | 2006-01-12 → 2006-01-16 (+4d) | 1d? → 9d |  | 0d → 212d |  | resources none → Mark Brown [33.3%]; baseline start 2006-01-12 → none; baseline finish 2006-01-12 → none |
| 189 | SE | 2006-01-04 → 2006-03-01 (+56d) | 2006-01-04 → 2006-03-14 (+69d) | 1d? → 10d |  | 6d → 171d | none → 62 | resources none → Brent; baseline start 2006-01-04 → none; baseline finish 2006-01-04 → none |
| 190 | Shop |  | 2006-01-04 → 2006-01-17 (+13d) | 1d? → 10d |  | 6d → 211d |  | baseline start 2006-01-04 → none; baseline finish 2006-01-04 → none |
| 193 | ME | 2006-01-05 → 2006-03-15 (+69d) | 2006-01-05 → 2006-03-20 (+74d) | 1d? → 4d |  | 0d → 171d | 148 → none | baseline start 2006-01-05 → none; baseline finish 2006-01-05 → none |
| 194 | SE | 2006-01-05 → 2006-03-15 (+69d) | 2006-01-05 → 2006-03-16 (+70d) | 1d? → 2d |  | 5d → 173d |  | resources none → Brent [50%]; baseline start 2006-01-05 → none; baseline finish 2006-01-05 → none |
| 197 | ME | 2006-01-12 → 2006-03-21 (+68d) | 2006-01-12 → 2006-03-28 (+75d) | 1d? → 6d |  | 0d → 174d |  | baseline start 2006-01-12 → none; baseline finish 2006-01-12 → none |
| 198 | SE | 2006-01-06 → 2006-03-21 (+74d) | 2006-01-06 → 2006-03-24 (+77d) | 1d? → 4d |  | 0d → 176d | 99 → none | resources none → Brent [50%]; baseline start 2006-01-06 → none; baseline finish 2006-01-06 → none |
| 202 | SE | 2006-01-12 → 2006-04-03 (+81d) | 2006-01-12 → 2006-04-03 (+81d) |  |  | 0d → 171d |  | resources none → Brent; baseline start 2006-01-12 → none; baseline finish 2006-01-12 → none |
| 206 | SE | 2006-01-06 → 2006-04-04 (+88d) | 2006-01-06 → 2006-04-04 (+88d) |  |  | 0d → 171d | 112 → none | resources none → Brent; baseline start 2006-01-06 → none; baseline finish 2006-01-06 → none |
| 210 | SE | 2006-01-12 → 2006-04-05 (+83d) | 2006-01-12 → 2006-04-05 (+83d) |  |  | 0d → 171d |  | resources none → Brent; baseline start 2006-01-12 → none; baseline finish 2006-01-12 → none |
| 214 | SE | 2006-01-06 → 2006-04-06 (+90d) | 2006-01-06 → 2006-04-06 (+90d) |  |  | 0d → 172d | 163 → none | resources none → Brent; baseline start 2006-01-06 → none; baseline finish 2006-01-06 → none |
| 215 | **Deploy D-ESP on ROV - 2, 1day dives (2mobs)** |  | 2006-01-04 → 2006-09-21 (+260d) | 1d? → 187d? |  | 6d → 52d |  |  |
| 223 | **Deployment** | 2006-01-12 → 2006-01-04 (-8d) | 2006-01-12 → 2006-01-04 (-8d) |  |  | 0d → 238d | 324 → none | baseline start 2006-01-04 → none; baseline finish 2006-01-04 → none |
| 233 | **Deployment** | 2006-01-12 → 2006-01-04 (-8d) | 2006-01-12 → 2006-01-04 (-8d) |  |  | 0d → 238d | Shop → none | baseline start 2006-03-08 → none; baseline finish 2006-03-08 → none |
| 237 | **Power Supply and Communication** |  |  |  |  | 6d → 238d |  | was named Power Supply |
| 240 | SE | 2006-01-12 → 2006-01-04 (-8d) | 2006-01-12 → 2006-01-04 (-8d) |  |  | 0d → 238d |  | baseline start 2006-01-12 → none; baseline finish 2006-01-12 → none |
| 245 | Shop |  |  |  |  | 6d → 238d |  | baseline start 2006-01-04 → none; baseline finish 2006-01-04 → none |
| 246 | **MARS deployment** |  | 2006-01-04 → 2006-12-04 (+334d) | 1d? → 239d? |  | 6d → 0d |  |  |
| 248 | **MOB** |  | 2006-01-11 → 2006-12-04 (+327d) | 6d? → 239d? |  |  |  |  |
| 251 | SE | 2006-01-06 → 2006-01-04 (-2d) | 2006-01-06 → 2006-01-04 (-2d) |  |  | 0d → 238d | 180 → none | baseline start 2006-01-06 → none; baseline finish 2006-01-06 → none |
| 254 | Shop |  |  |  |  | 6d → 238d |  | baseline start 2006-01-04 → none; baseline finish 2006-01-04 → none |
| 259 | SE | 2006-01-12 → 2006-01-04 (-8d) | 2006-01-12 → 2006-01-04 (-8d) |  |  | 0d → 238d |  | baseline start 2006-01-12 → none; baseline finish 2006-01-12 → none |
| 262 | Shop |  |  |  |  | 6d → 238d |  | baseline start 2006-01-04 → none; baseline finish 2006-01-04 → none |
| 266 | Sci |  |  |  |  | 6d → 238d |  | resources Chris S. → none; baseline start 2006-01-04 → none; baseline finish 2006-01-04 → none |
| 267 | Sci Tech |  |  |  |  | 6d → 238d |  | resources Roman → none; baseline start 2006-01-04 → none; baseline finish 2006-01-04 → none |
| 270 | SE | 2006-01-06 → 2006-01-04 (-2d) | 2006-01-06 → 2006-01-04 (-2d) |  |  | 0d → 238d | 193 → none | baseline start 2006-01-06 → none; baseline finish 2006-01-06 → none |
| 273 | Sci Tech |  |  |  |  | 6d → 238d |  | resources Roman → none; baseline start 2006-01-04 → none; baseline finish 2006-01-04 → none |
| 276 | SE | 2006-01-12 → 2006-01-04 (-8d) | 2006-01-12 → 2006-01-04 (-8d) |  |  | 0d → 238d |  | baseline start 2006-01-12 → none; baseline finish 2006-01-12 → none |
| 290 | Shop |  |  |  |  | 6d → 238d |  | baseline start 2006-01-04 → none; baseline finish 2006-01-04 → none |
| 299 | Shop |  |  |  |  | 6d → 238d |  | baseline start 2006-01-04 → none; baseline finish 2006-01-04 → none |
| 307 | Shop |  |  |  |  | 6d → 238d |  | baseline start 2006-01-04 → none; baseline finish 2006-01-04 → none |
| 315 | Shop | 2006-01-05 → 2006-01-04 (-1d) | 2006-01-05 → 2006-01-04 (-1d) |  |  | 5d → 238d |  | baseline start 2006-01-05 → none; baseline finish 2006-01-05 → none |
| 324 | Shop | 2006-01-11 → 2006-01-04 (-7d) | 2006-01-11 → 2006-01-04 (-7d) |  |  | 0d → 238d | EETech → none | baseline start 2006-01-11 → none; baseline finish 2006-01-11 → none |
| 349 | Shop | 2006-01-12 → 2006-01-04 (-8d) | 2006-01-12 → 2006-01-04 (-8d) |  |  | 0d → 238d |  | baseline start 2006-01-12 → none; baseline finish 2006-01-12 → none |
